# holgraphy at ATF

Schedule from MS Project, 2005-11-01 to 2007-03-22, A marks actual dates.
ALMA

## Calendars

- Standard: Mon-Fri 08:00-12:00, 13:00-17:00; Sat-Sun off. Exceptions (off unless hours are given): 2006-09-04, 2006-10-09, 2006-11-23 to 2006-11-24, 2006-12-25 to 2006-12-29, 2007-01-01 to 2007-01-02.

## Resources

| Resource |
| --- |
| Debra S |
| Jeff M |
| Robert Lucas |

## Schedule

| ID | WBS | Task | Type | Duration | Start | Finish | Predecessors | Complete | Remaining | Total slack | Constraint | Deadline | Text1 |
| --- | --- | --- | --- | --- | --- | --- | --- | --- | --- | --- | --- | --- | --- |
| 1 | 1 | **Holography System** |  | 352d | 2005-11-01 A | 2007-03-22 |  | 81% | 66.37d | 0d |  |  |  |
| 2 | 1.1 | Develop transmitter electronics |  | 30w | 2005-11-01 A | 2006-05-29 A |  | 100% |  |  | start no earlier than 2005-11-01 |  | Antonio |
| 3 | 1.2 | Repackage holography receiver |  | 32w | 2005-11-01 A | 2006-06-12 A |  | 100% |  |  | start no earlier than 2005-11-01 |  | Antonio |
| 4 | 1.3 | Develop ancillary electronics (cabling, power supply, ABM, TE and 25MHz, etc.) |  | 30w | 2005-11-01 A | 2006-05-29 A |  | 100% |  |  | start no earlier than 2005-11-01 |  | Antonio |
| 5 | 1.4 | Develop control software |  | 10w | 2006-03-13 A | 2006-05-19 A |  | 100% |  |  | start no earlier than 2006-03-12 |  | Brian |
| 6 | 1.5 | Modify reduction software for data format |  | 10d | 2006-03-13 | 2006-03-24 |  |  |  | 247d | start no earlier than 2006-03-12 |  | Robert |
| 7 | 1.6 | Ship Tx cables and spare minirack to AOC |  | 5d | 2006-08-07 A | 2006-08-11 A |  | 100% |  |  | start no earlier than 2006-08-07 |  |  |
| 9 | 1.7 | **NTC: Rx and Tx** |  | 57d | 2006-06-19 A | 2006-09-06 A |  | 100% |  |  |  |  |  |
| 10 | 1.7.1 | Integrate/test tx, rx at CV |  | 40d | 2006-06-19 A | 2006-08-11 A | 2, 3, 4, 5 | 100% |  |  | finish no earlier than 2006-08-11 |  | Antonio |
| 11 | 1.7.2 | System test at NTC |  | 4d | 2006-08-25 A | 2006-08-30 A | 10 | 100% |  |  | finish no earlier than 2006-08-30 |  |  |
| 12 | 1.7.3 | Pack |  | 1d | 2006-08-31 A | 2006-08-31 A | 11 | 100% |  |  |  |  | Antonio |
| 13 | 1.7.4 | Ship to AOC |  | 3d | 2006-09-01 A | 2006-09-06 A | 12 | 100% |  |  |  |  | Antonio |
| 14 | 1.7.5 | Receive Tx and Rx at AOC | milestone | 0d | 2006-09-06 A | 2006-09-06 A | 13 | 100% |  |  |  |  |  |
| 16 | 1.8 | **AOC and ATF preparation** |  | 31d | 2006-08-14 A | 2006-09-26 A |  | 100% |  |  |  |  |  |
| 17 | 1.8.1 | Inspect Tower |  | 1d | 2006-08-14 A | 2006-08-14 A |  | 100% |  |  | start no earlier than 2006-08-14 |  |  |
| 18 | 1.8.2 | Install Tx cables |  | 7d | 2006-08-28 A | 2006-09-06 A | 17, 7 | 100% |  |  | start no earlier than 2006-08-28 |  |  |
| 19 | 1.8.3 | Install Tx at ATF and verify control |  | 3d | 2006-09-07 A | 2006-09-11 A | 14, 18 | 100% |  |  |  |  | Dick, Antonio |
| 20 | 1.8.4 | Prepare RF cables |  | 5d | 2006-08-14 A | 2006-08-18 A |  | 100% |  |  | finish no earlier than 2006-08-18 |  |  |
| 21 | 1.8.5 | Control software checkout at AOC |  | 5d | 2006-09-11 A | 2006-09-15 A | 14 | 100% |  |  | start no earlier than 2006-09-11 |  |  |
| 22 | 1.8.6 | Install RF and FO cables on tower |  | 1d | 2006-09-18 A | 2006-09-18 A | 21, 20 | 100% |  |  |  |  |  |
| 23 | 1.8.7 | Upgrade software at ATF |  | 3d | 2006-09-19 A | 2006-09-21 A | 22 | 100% |  |  |  |  |  |
| 24 | 1.8.8 | Prepare for mounting minirack in both antennas |  | 5d | 2006-08-28 A | 2006-09-01 A |  | 100% |  |  | start no earlier than 2006-08-28 |  |  |
| 25 | 1.8.9 | Antenna VA / AEC decision | milestone | 0d | 2006-09-11 A | 2006-09-11 A | 13SS | 100% |  |  | start no earlier than 2006-09-11 | 2006-09-11 |  |
| 26 | 1.8.10 | prepare antenna for electronics |  | 5d | 2006-09-11 A | 2006-09-15 A | 25, 24 | 100% |  |  |  | 2006-08-09 |  |
| 27 | 1.8.11 | Install receiver |  | 2d | 2006-09-25 A | 2006-09-26 A | 26, 21 | 100% |  |  | start no earlier than 2006-09-25 |  |  |

| ID | WBS | Task | Type | Duration | Start | Finish | Predecessors | Complete | Remaining | Total slack | Free slack | Constraint |
| --- | --- | --- | --- | --- | --- | --- | --- | --- | --- | --- | --- | --- |
| 29 | 1.9 | **Checkout** |  | 8d | 2006-09-29 A | 2006-10-11 A | 27, 23 | 100% |  |  |  |  |
| 30 | 1.9.1 | Check M/C and 1st point of Tx |  | 5d | 2006-09-29 A | 2006-10-05 A |  | 100% |  |  |  | start no earlier than 2006-09-29 |
| 31 | 1.9.2 | Ensure Tx and Rx on correct frequency, confirm adequate received power |  | 1d | 2006-10-06 A | 2006-10-06 A | 30 | 100% |  |  |  |  |
| 32 | 1.9.3 | Peak transmitter pointing |  | 1d | 2006-10-10 A | 2006-10-10 A | 31 | 100% |  |  |  |  |
| 33 | 1.9.4 | Verify receiver complex output and stability |  | 1d | 2006-10-11 A | 2006-10-11 A | 32 | 100% |  |  |  |  |
| 35 | 1.10 | **e2e tests of the system** |  | 64d | 2006-10-12 A | 2007-01-22 | 29 | 17% | 53.22d | 43d |  |  |
| 36 | 1.10.1 | Verfy mount movement and synch with data |  | 3d | 2006-10-12 A | 2006-10-16 A |  | 100% |  |  |  |  |
| 37 | 1.10.2 | Verify writing/reading from archive |  | 1d | 2006-10-17 A | 2006-10-17 A | 36 | 100% |  |  |  |  |
| 38 | 1.10.3 | Perform 1st raster and create database |  | 2d | 2006-10-18 A | 2006-10-19 A | 37 | 100% |  |  |  |  |
| 39 | 1.10.4 | Confirm data analysis and display are working correctly |  | 1d | 2006-10-20 A | 2006-10-20 A | 38 | 100% |  |  |  |  |
| 40 | 1.10.5 | Produce first holo image |  | 1d | 2006-10-23 A | 2006-10-23 A | 39 | 100% |  |  |  |  |
| 41 | 1.10.6 | measure, adjust focus and illumination |  | 1d | 2006-10-24 A | 2006-10-24 A | 40 | 100% |  |  |  |  |
| 42 | 1.10.7 | Investigate saturation and illumination problems |  | 2d | 2006-10-30 A | 2006-10-31 A | 41 | 100% |  |  |  | start no earlier than 2006-10-30 |
| 43 | 1.10.8 | Temporary remedy improve frequency/phase stability |  | 5d | 2006-11-01 A | 2006-11-07 A | 42 | 100% |  |  |  |  |
| 44 | 1.10.9 | Investigate DSP problems |  | 5d | 2006-11-01 | 2006-11-07 | 42 |  |  | 87d |  |  |
| 45 | 1.10.10 | Install / check out data reduction software at ATF |  | 3d | 2006-11-01 | 2006-11-03 | 42 |  |  | 20d | 2d |  |
| 46 | 1.10.11 | Order stable reference oscillators | milestone | 0d | 2006-11-09 A | 2006-11-09 A | 42 | 100% |  |  |  | start no earlier than 2006-11-09 |
| 47 | 1.10.12 | Deliver stable reference oscillators |  | 6w | 2006-11-09 | 2006-12-22 | 46 |  |  | 41d | 0d |  |
| 48 | 1.10.13 | Install new references in Rack B |  | 10d | 2007-01-03 | 2007-01-16 | 47 |  |  | 41d | 0d |  |
| 49 | 1.10.14 | Ship rack to ATF |  | 2d | 2007-01-17 | 2007-01-18 | 48 |  |  | 41d | 0d |  |
| 50 | 1.10.15 | Exchange with Rack A, update transmitter reference |  | 2d | 2007-01-19 | 2007-01-22 | 47FF, 49 |  |  | 42d | 0d |  |
| 51 | 1.10.16 | Continue to investigate data quality problems |  | 10d | 2006-11-16 | 2006-12-01 |  |  |  | 0d |  | must start on 2006-11-16 |
| 52 | 1.10.17 | Stress Test |  | 3d | 2006-11-20 | 2006-11-22 |  |  |  | 0d |  | must start on 2006-11-20 |
| 53 | 1.10.18 | Install / test ACS6 |  | 10d | 2006-12-04 | 2006-12-15 |  |  |  | 0d |  | must start on 2006-12-04 |
| 54 | 1.10.19 | CIPT mini-test |  | 4d | 2006-12-18 | 2006-12-21 | 53 |  |  | 5d |  |  |

| ID | WBS | Task | Type | Duration | Start | Finish | Predecessors | Total slack | Constraint | Text1 |
| --- | --- | --- | --- | --- | --- | --- | --- | --- | --- | --- |
| 56 | 1.11 | **Science Validation** |  | 10d | 2007-01-09 | 2007-01-22 | 43 | 0d |  |  |
| 57 | 1.11.1 | User test |  | 5d | 2007-01-09 | 2007-01-15 | 54 | 0d | start no earlier than 2007-01-09 |  |
| 58 | 1.11.2 | Punchlist cleanup |  | 5d | 2007-01-16 | 2007-01-22 | 57 | 0d |  |  |
| 60 | 1.12 | Test Readiness Review |  | 1d | 2007-01-23 | 2007-01-23 | 58, 50 | 41d |  |  |
| 61 | 1.13 | Acceptance tests |  | 2d | 2007-01-23 | 2007-01-24 | 56 | 0d |  | Rick |
| 62 | 1.14 | Plan way forward |  | 2d | 2007-01-23 | 2007-01-24 | 61SS | 41d |  |  |
| 63 | 1.15 | Margin |  | 5d | 2007-01-25 | 2007-01-31 | 61 | 0d |  |  |
| 64 | 1.16 | Remove Rx from antenna, replace SR |  | 1d | 2007-02-01 | 2007-02-01 | 63 | 0d |  |  |
| 65 | 1.17 | Pack up |  | 5d | 2007-02-02 | 2007-02-08 | 64 | 0d |  | Dick |
| 66 | 1.18 | ship to Chile |  | 20d | 2007-02-09 | 2007-03-08 | 65 | 0d |  |  |
| 67 | 1.19 | Reconfigure sofware, install, test functionality in lab. |  | 10d | 2007-03-09 | 2007-03-22 | 66 | 0d | start no earlier than 2006-08-17 | Brian, Darre, Robert, AIV |
| 68 | 1.20 | Holography system ready for installation in first antenna. | milestone | 0d | 2007-03-22 | 2007-03-22 | 67 | 0d |  |  |
